# GD-06 - alleen plat dak

Schedule from MS Project, 2003-01-12 to 2003-01-26, status date 2003-01-08.
BAM Nelissen Van Egteren

## Calendars

- ALLEEN WERKDAGEN: Mon-Fri 08:30-12:30, 13:00-17:00; Sat-Sun off. Exceptions (off unless hours are given): 2003-01-11 to 2003-01-12 08:30-12:30, 13:00-17:00, 2003-01-18 to 2003-01-19 08:30-12:30, 13:00-17:00, 2003-01-25 to 2003-01-26 08:30-12:30, 13:00-17:00.

## Schedule

| ID | WBS | Task | Type | Duration | Start | Finish | Predecessors | Total slack |
| --- | --- | --- | --- | --- | --- | --- | --- | --- |
| 1 | 1 | **GEVEL/DAK FASE** |  | 15d | 2003-01-12 | 2003-01-26 |  | 0d |
| 2 | 1.1 | gevel is gereed en waterdicht |  | 1d | 2003-01-12 | 2003-01-12 |  | 0d |
| 3 | 1.2 | dakbalklaag+ravelingen aanbr. |  | 5d | 2003-01-12 | 2003-01-16 | 2SS | 0d |
| 4 | 1.3 | dakplaten leggen |  | 5d | 2003-01-16 | 2003-01-20 | 3SS+4d | 0d |
| 5 | 1.4 | dakranden+dakdoorvoeren |  | 5d | 2003-01-18 | 2003-01-22 | 4SS+2d | 0d |
| 6 | 1.5 | dakisolatie aanbrengen |  | 5d | 2003-01-20 | 2003-01-24 | 5SS+2d | 0d |
| 7 | 1.6 | dakbedekking aanbrengen |  | 5d | 2003-01-22 | 2003-01-26 | 6SS+2d | 0d |
| 8 | 1.7 | start afbouw fase | milestone | 0d | 2003-01-26 | 2003-01-26 | 7SS+5d | 0d |
